# Cavity Dressing schedule-Jan19_09

Schedule from MS Project, 2008-06-09 to 2010-02-04.
Fermilab

## Calendars

- Standard: Mon-Fri 08:00-12:00, 13:00-17:00; Sat-Sun off. Exceptions (off unless hours are given): 2008-07-04, 2008-09-01, 2008-11-27 to 2008-11-28, 2008-12-24 to 2008-12-26, 2008-12-31 to 2009-01-02, 2009-01-19.

## Resources

| Resource |
| --- |
| CG |
| DM |
| YO |
| EB |
| MF |
| PP |
| PO |
| RE |
| JZ |
| TB |
| EF |
| MW |
| TP |
| TA |
| GS |
| MS |
| TK |
| ? |
| RH |
| PP<RH |
| MR |
| RW |

## Schedule

| ID | WBS | Task | Type | Duration | Start | Finish | Predecessors | Total slack | Free slack | Constraint | Resources | Work |
| --- | --- | --- | --- | --- | --- | --- | --- | --- | --- | --- | --- | --- |
| 1 | 1 | **Dress first 1.3GHz cavity with Ti Helium Vessel** |  | 422.5d | 2008-06-09 | 2010-02-04 |  | 0d |  |  |  | 25504h |
| 2 | 1.1 | **Mechanical Design** |  | 150d | 2008-06-09 | 2009-01-16 |  | 58d | 0d |  | CG; DM | 6160h |
| 3 | 1.1.1 | Receive Light Blade Tuner drawings from INFN | milestone | 0d | 2008-06-09 | 2008-06-09 |  | 64d | 0d | start no earlier than 2008-06-09 | DM |  |
| 4 | 1.1.2 | Update CM2 Solid Model |  | 10d | 2008-06-09 | 2008-06-20 | 3 | 64d | 0d |  | YO | 80h |
| 5 | 1.1.3 | Release Helium Vessel Raw Tube Drawings |  | 5d | 2008-06-23 | 2008-06-27 | 4 | 181d | 0d |  | CG | 40h |
| 6 | 1.1.4 | Release Titanium Bellows Drawings for RFP |  | 5d | 2008-06-23 | 2008-06-27 | 4 | 64d | 0d |  | CG | 40h |
| 7 | 1.1.5 | Release Actual Weld Samples Drawings |  | 30d | 2008-06-30 | 2008-08-11 | 6 | 64d | 0d |  | CG | 240h |
| 8 | 1.1.6 | **Complete the final Design of the Components & Release Drawings** |  | 5d | 2009-01-12 | 2009-01-16 | 25 | 58d | 0d |  | CG | 160h |
| 9 | 1.1.6.1 | Transition parts |  | 5d | 2009-01-12 | 2009-01-16 | 24 | 64d |  |  | CG | 40h |
| 10 | 1.1.6.2 | Blade Tuner Rings |  | 5d | 2009-01-12 | 2009-01-16 | 24 | 64d |  |  | CG | 40h |
| 11 | 1.1.6.3 | Miscs. components |  | 5d | 2009-01-12 | 2009-01-16 | 24 | 64d |  |  | CG | 40h |
| 12 | 1.1.7 | **Complete the final Design of the Assembly & Welding Fixtures** |  | 80d | 2008-08-01 | 2008-11-21 |  | 139d | 32d |  | EB | 3200h |
| 13 | 1.1.7.1 | Insertion & Alignment Fixture |  | 80d | 2008-08-01 | 2008-11-21 |  | 145d | 0d | start no earlier than 2008-08-01 | EB | 640h |
| 14 | 1.1.7.2 | Dressed Cavity Handling Fixture |  | 80d | 2008-08-01 | 2008-11-21 |  | 145d | 0d | start no earlier than 2008-08-01 | EB | 640h |
| 15 | 1.1.7.3 | Dressed Cavity Handling Cage |  | 80d | 2008-08-01 | 2008-11-21 |  | 145d | 0d | start no earlier than 2008-08-01 | EB | 640h |
| 16 | 1.1.7.4 | E-beam & TIG Welding Fixtures |  | 80d | 2008-08-01 | 2008-11-21 |  | 145d | 0d | start no earlier than 2008-08-01 | EB | 640h |
| 17 | 1.2 | Design and Drawings Release Complete | milestone | 0d | 2009-01-16 | 2009-01-16 | 2, 12 | 42d |  |  |  |  |
| 18 | 1.3 | **Welding Tests** |  | 144d | 2008-06-10 | 2009-01-09 |  | 102d |  |  | MF | 3192h |
| 19 | 1.3.1 | Flat Samples Welding Fixtures Fabrication | milestone | 0d | 2008-06-23 | 2008-06-23 |  | 353d |  | start no earlier than 2008-06-23 | PP; MF |  |
| 20 | 1.3.2 | Flat Weld Samples preparation (Ti, NbTi) |  | 10d | 2008-06-10 | 2008-06-23 |  | 322d | 0d | start no earlier than 2008-06-10 | PP; MF | 160h |
| 21 | 1.3.3 | Actual Weld Samples preparation (Ti, NbTi) |  | 85d | 2008-08-12 | 2008-12-11 | 7 | 64d | 0d |  | PP; MF | 1360h |
| 22 | 1.3.4 | Weld Samples Cutting from the non-acceptable titanium tube (in-house) |  | 20d | 2008-09-02 | 2008-09-29 |  | 115d | 51d | start no earlier than 2008-09-02 | PP | 160h |
| 23 | 1.3.5 | Conduct Welding Tests with Flat Samples (EBW) |  | 30d | 2008-06-24 | 2008-08-05 | 20 | 322d |  |  | MF | 240h |
| 24 | 1.3.6 | Conduct Welding Tests with Actual Samples (EBW) |  | 15d | 2008-12-12 | 2009-01-09 | 21, 22 | 64d | 0d |  | MF | 120h |
| 25 | 1.4 | Welding Tests Complete | milestone | 0d | 2009-01-09 | 2009-01-09 | 24 | 16d | 0d |  |  |  |

| ID | WBS | Task | Type | Duration | Start | Finish | Predecessors | Total slack | Free slack | Constraint | Resources | Work |
| --- | --- | --- | --- | --- | --- | --- | --- | --- | --- | --- | --- | --- |
| 26 | 1.5 | **Procurement** |  | 303d | 2008-06-30 | 2009-09-11 |  | 104.5d |  |  |  | 15424h |
| 27 | 1.5.1 | **Titanium Raw tubes for Helium Vessel Fabrication ( prototypes)** |  | 167d | 2008-06-30 | 2009-03-04 |  | 240.5d | 136d |  | PO | 4008h |
| 28 | 1.5.1.1 | Get Quotes from vendors |  | 40d | 2008-06-30 | 2008-08-25 | 5 | 181d | 0d |  | PO | 320h |
| 29 | 1.5.1.2 | Place Order for titanium Tubes (4) from Ameriflex & Hi Tech Total=8 |  | 5d | 2008-08-26 | 2008-09-02 | 28 | 181d | 0d |  | PO | 40h |
| 30 | 1.5.1.3 | **Titanium Tubes (4) from Ameriflex** |  | 100d | 2008-09-03 | 2009-02-02 |  | 262.5d |  |  | PO | 800h |
| 31 | 1.5.1.3.1 | Receive tubes |  | 65d | 2008-09-03 | 2008-12-04 | 29 | 203d | 0d |  |  |  |
| 32 | 1.5.1.3.2 | Inspect tubes |  | 10d | 2008-12-05 | 2008-12-18 | 31 | 203d | 0d |  |  |  |
| 33 | 1.5.1.3.3 | Machine accepted tubes at Ameriflex, ship back to Fermilab |  | 20d | 2008-12-19 | 2009-01-26 | 32 | 203d | 0d |  |  |  |
| 34 | 1.5.1.3.4 | Inspect tubes returned from Ameriflex |  | 5d | 2009-01-27 | 2009-02-02 | 33 | 203d | 0d |  |  |  |
| 35 | 1.5.1.3.5 | Tubes ready for use | milestone | 0d | 2009-02-02 | 2009-02-02 | 34 | 203d |  |  |  |  |
| 36 | 1.5.1.4 | **Titanium Tubes (4) from Hi Tech** |  | 109d | 2008-09-03 | 2009-02-13 |  | 240.5d |  |  | PO | 872h |
| 37 | 1.5.1.4.1 | Receive prototype tubes (2) |  | 85d | 2008-09-03 | 2009-01-09 | 29 | 181d | 0d |  |  |  |
| 38 | 1.5.1.4.2 | Inspect tubes |  | 4d | 2009-01-12 | 2009-01-15 | 37 | 181d | 0d |  |  |  |
| 39 | 1.5.1.4.3 | Weld remaining tubes (2) |  | 10d | 2009-01-16 | 2009-01-30 | 38 | 194d | 0d |  |  |  |
| 40 | 1.5.1.4.4 | Receive remaining tubes and inspect |  | 10d | 2009-02-02 | 2009-02-13 | 39 | 194d | 0d |  |  |  |
| 41 | 1.5.1.4.5 | Tubes ready for use | milestone | 0d | 2009-02-13 | 2009-02-13 | 40 | 194d |  |  |  |  |
| 42 | 1.5.1.5 | **Titanium tube from GE Mathis / Hi Tech (Alternative Fabrication Method Evaluation)** |  | 40d | 2008-08-01 | 2008-09-26 |  | 344.5d |  |  | PO | 640h |
| 43 | 1.5.1.5.1 | Roll Titanium Tube Halves (prototype) |  | 10d | 2008-08-01 | 2008-08-14 |  | 285d | 0d | start no earlier than 2008-08-01 | PO | 80h |
| 44 | 1.5.1.5.2 | Weld Tube Halves (prototype) |  | 25d | 2008-08-15 | 2008-09-19 | 43 | 285d | 0d |  | PO | 200h |
| 45 | 1.5.1.5.3 | QC & Evaluate the prototype |  | 5d | 2008-09-22 | 2008-09-26 | 44 | 285d |  |  | PO | 40h |
| 46 | 1.5.1.6 | **Select Vendor and Order Remaining Tubes** |  | 33d | 2009-01-16 | 2009-03-04 |  | 240.5d |  |  |  |  |
| 47 | 1.5.1.6.1 | Hi Tech Selected as Vendor for Remaining Tubes (16) |  | 1d | 2009-01-16 | 2009-01-16 | 38 | 181d | 0d |  |  |  |
| 48 | 1.5.1.6.2 | Order 16 Tubes from Hi Tech |  | 2d | 2009-01-20 | 2009-01-21 | 47 | 181d | 0d |  |  |  |
| 49 | 1.5.1.6.3 | Tube Fabrication Complete and tubes ready for use in subassemblies |  | 30d | 2009-01-22 | 2009-03-04 | 48 | 181d |  |  |  |  |

| ID | WBS | Task | Type | Duration | Start | Finish | Predecessors | Total slack | Free slack | Constraint | Resources | Work |
| --- | --- | --- | --- | --- | --- | --- | --- | --- | --- | --- | --- | --- |
| 50 | 1.5.2 | **Titanium Bellows** |  | 151d | 2008-06-30 | 2009-02-10 |  | 256.5d | 152d |  | RE; PO | 4176h |
| 51 | 1.5.2.1 | Get RFP for design optimization from vendors |  | 40d | 2008-06-30 | 2008-08-25 | 6 | 238d | 0d |  | RE; PO | 640h |
| 52 | 1.5.2.2 | Place order for titanium bellows (20 from Ameriflex) |  | 5d | 2008-08-26 | 2008-09-02 | 51 | 238d | 0d |  | RE; PO | 80h |
| 53 | 1.5.2.3 | Receive titanium bellows |  | 65d | 2008-09-03 | 2008-12-04 | 52 | 238d |  |  | RE; PO | 1040h |
| 54 | 1.5.2.4 | Inspect and leak check bellows |  | 25d | 2009-01-06 | 2009-02-10 |  | 256.5d | 0d | start no earlier than 2009-01-06 |  |  |
| 55 | 1.5.2.5 | Bellows ready for use | milestone | 0d | 2009-02-10 | 2009-02-10 | 54 | 197d |  |  |  |  |
| 56 | 1.5.3 | **Helium Vessel Subassemblies** |  | 293d | 2008-07-15 | 2009-09-11 |  | 60d | 0d |  | PO; JZ | 5800h |
| 57 | 1.5.3.1 | Place order with HiTech |  | 19d | 2009-01-20 | 2009-02-13 | 8 | 64d | 0d |  | RE | 152h |
| 58 | 1.5.3.2 | Receive prototype vessel subassembly for AES1 |  | 60d | 2009-02-16 | 2009-05-08 | 57 | 64d | 0d |  | PO; JZ | 960h |
| 59 | 1.5.3.3 | Receive 2nd for AES4 | milestone | 0d | 2009-05-29 | 2009-05-29 |  | 52d | 0d | start no earlier than 2009-05-29 | PO; JZ |  |
| 60 | 1.5.3.4 | Receive 3th vessel & QC | milestone | 0d | 2008-07-15 | 2008-07-15 |  | 289d | 283d | start no earlier than 2008-07-15 | PO; JZ |  |
| 61 | 1.5.3.5 | Receive 4th vessel & QC | milestone | 0d | 2009-07-15 | 2009-07-15 |  | 38d | 32d | start no earlier than 2009-07-15 | PO; JZ |  |
| 62 | 1.5.3.6 | Receive 5th vessel & QC | milestone | 0d | 2009-08-07 | 2009-08-07 |  | 34d | 30d | start no earlier than 2009-08-07 | PO; JZ |  |
| 63 | 1.5.3.7 | Receive 6th vessel & QC | milestone | 0d | 2009-08-14 | 2009-08-14 |  | 29d | 25d | start no earlier than 2009-08-14 | PO; JZ |  |
| 64 | 1.5.3.8 | Receive 7th vessel & QC | milestone | 0d | 2009-08-21 | 2009-08-21 |  | 37d | 35d | start no earlier than 2009-08-21 | PO; JZ |  |
| 65 | 1.5.3.9 | Receive 8th vessel & QC | milestone | 0d | 2009-08-28 | 2009-08-28 |  | 32d | 30d | start no earlier than 2009-08-28 | PO; JZ |  |
| 66 | 1.5.3.10 | Receive 9th vessel & QC | milestone | 0d | 2009-09-04 | 2009-09-04 |  | 40d |  | start no earlier than 2009-09-04 | PO; JZ |  |
| 67 | 1.5.3.11 | Receive 10th vessel & QC | milestone | 0d | 2009-09-11 | 2009-09-11 |  | 35d |  | start no earlier than 2009-09-11 | PO; JZ |  |
| 68 | 1.5.4 | **Assembly & Welding Fixtures** |  | 30d | 2008-11-24 | 2009-01-14 |  | 139d | 0d |  | EB; PO | 1440h |
| 69 | 1.5.4.1 | Insertion and Alignment Fixture Parts Available |  | 30d | 2008-11-24 | 2009-01-14 | 13 | 145d |  |  | PO | 240h |
| 70 | 1.5.4.2 | Dressed Cavity Handling Fixture Parts Available |  | 30d | 2008-11-24 | 2009-01-14 | 14 | 145d |  |  | PO | 240h |
| 71 | 1.5.4.3 | Dressed Cavity Handling Cage Parts Available |  | 30d | 2008-11-24 | 2009-01-14 | 15 | 145d |  |  | PO | 240h |
| 72 | 1.5.4.4 | Welding Fixtures Parts Available |  | 30d | 2008-11-24 | 2009-01-14 | 16 | 145d |  |  | PO | 240h |
| 73 | 1.6 | Procurements Complete | milestone | 0d | 2009-09-11 | 2009-09-11 | 27, 50, 56, 68 | 45d |  |  |  |  |
| 74 | 1.7 | Assemble Tooling and Welding Fixtures at CAF-MP9 | milestone | 0d | 2009-01-14 | 2009-01-14 | 68 | 274.5d |  |  | GS |  |

| ID | WBS | Task | Type | Duration | Start | Finish | Predecessors | Total slack | Free slack | Constraint | Resources | Work |
| --- | --- | --- | --- | --- | --- | --- | --- | --- | --- | --- | --- | --- |
| 75 | 1.8 | **Ti rings e-beam welding to the Cavity at Sciaky** |  | 120d | 2009-05-15 | 2009-10-30 |  | 69.5d |  |  |  |  |
| 76 | 1.8.1 | AES-1 | milestone | 0d | 2009-05-15 | 2009-05-15 |  | 130d |  | start no earlier than 2009-05-15 |  |  |
| 77 | 1.8.2 | AES-4 | milestone | 0d | 2009-05-29 | 2009-05-29 |  | 120d |  | start no earlier than 2009-05-29 |  |  |
| 78 | 1.8.3 | Cavity #1 & #2 for CM2 | milestone | 0d | 2009-08-28 | 2009-08-28 |  | 0d |  | start no earlier than 2009-08-28 |  |  |
| 79 | 1.8.4 | Cavity #3 & #4 for CM2 | milestone | 0d | 2009-09-18 | 2009-09-18 |  | 4d | 0d | start no earlier than 2009-09-18 |  |  |
| 80 | 1.8.5 | Cavity #4 & #6 for CM2 | milestone | 0d | 2009-10-09 | 2009-10-09 |  | 2d | 0d | start no earlier than 2009-10-09 |  |  |
| 81 | 1.8.6 | Cavity #7 & #8 for CM2 | milestone | 0d | 2009-10-30 | 2009-10-30 |  | 7.5d | 0d | start no earlier than 2009-10-30 |  |  |
| 82 | 1.9 | **Assemble Helium Vessel to AES1 & AES4 at CAF-MP9** |  | 24d | 2009-05-11 | 2009-06-11 | 68 | 52d |  |  | TA | 288h |
| 83 | 1.9.1 | Vessel to Cavity Insertion & Alignment |  | 1d | 2009-05-11 | 2009-05-11 | 68, 58 | 64d | 0d |  | TA | 8h |
| 84 | 1.9.2 | Tack Weld & Monitor the field flatness |  | 1d | 2009-05-12 | 2009-05-12 | 83 | 64d | 0d |  | TA; TK | 16h |
| 85 | 1.9.3 | TIG Welding in the glove box |  | 3d | 2009-05-13 | 2009-05-15 | 84 | 64d | 0d |  | GS | 24h |
| 86 | 1.9.4 | QA |  | 3d | 2009-05-18 | 2009-05-20 | 85 | 64d | 0d |  | TB; TK | 48h |
| 87 | 1.9.5 | 1st Dressed Cavity (AES1) Complete | milestone | 0d | 2009-05-20 | 2009-05-20 | 86 | 64d | 0d |  |  |  |
| 88 | 1.9.6 | 2nd Dressed Cavity (AES-4) Complete |  | 10d | 2009-05-29 | 2009-06-11 | 87, 59 | 52d |  |  |  |  |
| 89 | 1.10 | **Assemble Helium Vessel to CM2 cavities at CAF-MP9** |  | 55d | 2009-08-28 | 2009-11-12 |  | 0d |  |  | TA | 440h |
| 90 | 1.10.1 | Cavity #1 & #2 for CM2 |  | 10d | 2009-08-28 | 2009-09-10 | 88FS+3d, 60, 61, 78 | 0d |  |  |  |  |
| 91 | 1.10.2 | Cavity #3 & #4 for CM2 |  | 10d | 2009-09-18 | 2009-10-01 | 90FS+3d, 62, 63, 79 | 3d | 0d |  |  |  |
| 92 | 1.10.3 | Cavity #4 & #6 for CM2 |  | 10d | 2009-10-09 | 2009-10-22 | 91FS+3d, 64, 65, 80 | 14d | 0d |  |  |  |
| 93 | 1.10.4 | Cavity #7 & #8 for CM2 |  | 10d | 2009-10-30 | 2009-11-12 | 92FS+3d, 66, 67, 81 | 25d | 0d |  |  |  |
| 95 | 1.11 | **Test Cycle for AES1** |  | 48d | 2009-07-20 | 2009-09-23 |  | 95.5d |  |  |  |  |
| 96 | 1.11.1 | Transport dressed cavity to ANL for HPR |  | 0.5d | 2009-07-20 | 2009-07-20 | 87FS+5d | 129d | 0d | start no earlier than 2009-07-20 |  |  |
| 97 | 1.11.2 | HPR Cavity |  | 4d | 2009-07-20 | 2009-07-24 | 96 | 129d | 0d |  |  |  |
| 98 | 1.11.3 | Prep cavity for horizontal testing at CAF-MP9 |  | 10d | 2009-07-24 | 2009-08-07 | 97 | 129d |  |  |  |  |
| 99 | 1.11.4 | Complete the engineering note and acquire test permission | milestone | 0d | 2009-08-31 | 2009-08-31 |  | 95.5d | 0d | start no earlier than 2009-08-31 |  |  |
| 100 | 1.11.5 | Install in HTS |  | 3d | 2009-08-31 | 2009-09-02 | 99 | 95.5d | 0d |  |  |  |
| 101 | 1.11.6 | Conduct tests |  | 15d | 2009-09-03 | 2009-09-23 | 100, 99 | 95.5d | 0d |  |  |  |
| 102 | 1.11.7 | Test Cycle complete for AES1 | milestone | 0d | 2009-09-23 | 2009-09-23 | 101 | 95.5d |  |  |  |  |

| ID | WBS | Task | Type | Duration | Start | Finish | Predecessors | Total slack | Free slack | Constraint |
| --- | --- | --- | --- | --- | --- | --- | --- | --- | --- | --- |
| 104 | 1.12 | **Test Cycle for AES4** |  | 21.5d | 2009-09-01 | 2009-09-30 |  | 91d |  |  |
| 105 | 1.12.1 | Transport dressed cavity to ANL for HPR |  | 0.5d | 2009-09-01 | 2009-09-01 |  | 91d | 0d | start no earlier than 2009-09-01 |
| 106 | 1.12.2 | HPR Cavity |  | 3d | 2009-09-01 | 2009-09-04 | 105 | 91d | 0d |  |
| 107 | 1.12.3 | Prep cavity for horizontal testing at CAF-MP9 |  | 5d | 2009-09-04 | 2009-09-11 | 106 | 91d | 0d |  |
| 108 | 1.12.4 | Complete the engineering note and acquire test permission | milestone | 0d | 2009-09-07 | 2009-09-07 |  | 98.5d | 7.5d | start no earlier than 2009-09-07 |
| 109 | 1.12.5 | Install in HTS |  | 3d | 2009-09-11 | 2009-09-16 | 107 | 91d | 0d |  |
| 110 | 1.12.6 | Conduct tests |  | 10d | 2009-09-16 | 2009-09-30 | 108, 109 | 91d | 0d |  |
| 111 | 1.12.7 | Test Cycle complete for AES4 | milestone | 0d | 2009-09-30 | 2009-09-30 | 110 | 91d |  |  |
| 113 | 1.13 | **Test Cycle for CM2 Cavity #1** |  | 25.5d | 2009-09-07 | 2009-10-12 |  | 83d |  |  |
| 114 | 1.13.1 | Transport dressed cavity to ANL for HPR |  | 0.5d | 2009-09-11 | 2009-09-11 | 90 | 83d | 0d | start no earlier than 2009-09-01 |
| 115 | 1.13.2 | HPR Cavity |  | 3d | 2009-09-11 | 2009-09-16 | 114 | 83d | 0d |  |
| 116 | 1.13.3 | Prep cavity for horizontal testing at CAF-MP9 |  | 5d | 2009-09-16 | 2009-09-23 | 115 | 83d | 0d |  |
| 117 | 1.13.4 | Complete the engineering note and acquire test permission | milestone | 0d | 2009-09-07 | 2009-09-07 |  | 98.5d | 15.5d | start no earlier than 2009-09-07 |
| 118 | 1.13.5 | Install in HTS |  | 3d | 2009-09-23 | 2009-09-28 | 116 | 83d | 0d |  |
| 119 | 1.13.6 | Conduct tests |  | 10d | 2009-09-28 | 2009-10-12 | 117, 118 | 83d | 0d |  |
| 120 | 1.13.7 | Test Cycle complete Cavity #1 | milestone | 0d | 2009-10-12 | 2009-10-12 | 119 | 83d |  |  |
| 122 | 1.14 | **Test Cycle for CM2 Cavity #2** |  | 21.5d | 2009-09-18 | 2009-10-19 |  | 0d |  |  |
| 123 | 1.14.1 | Transport dressed cavity to ANL for HPR |  | 0.5d | 2009-09-18 | 2009-09-18 | 90FS+5d | 0d |  | start no earlier than 2009-09-11 |
| 124 | 1.14.2 | HPR Cavity |  | 3d | 2009-09-18 | 2009-09-23 | 123 | 0d |  | start no earlier than 2009-09-11 |
| 125 | 1.14.3 | Prep cavity for horizontal testing at CAF-MP9 |  | 5d | 2009-09-23 | 2009-09-30 | 124 | 0d |  | start no earlier than 2009-09-16 |
| 126 | 1.14.4 | Complete the engineering note and acquire test permission | milestone | 0d | 2009-09-21 | 2009-09-21 |  | 10.5d |  | start no earlier than 2009-09-21 |
| 127 | 1.14.5 | Install in HTS |  | 3d | 2009-09-30 | 2009-10-05 | 125 | 0d |  | start no earlier than 2009-09-23 |
| 128 | 1.14.6 | Conduct tests |  | 10d | 2009-10-05 | 2009-10-19 | 126, 127 | 0d |  | start no earlier than 2009-09-28 |
| 129 | 1.14.7 | Test Cycle complete Cavity #2 | milestone | 0d | 2009-10-19 | 2009-10-19 | 128 | 0d |  | start no earlier than 2009-10-12 |

| ID | WBS | Task | Type | Duration | Start | Finish | Predecessors | Total slack | Free slack | Constraint |
| --- | --- | --- | --- | --- | --- | --- | --- | --- | --- | --- |
| 131 | 1.15 | **Test Cycle for CM2 Cavity #3** |  | 24.5d | 2009-10-02 | 2009-11-05 |  | 0d |  |  |
| 132 | 1.15.1 | Transport dressed cavity to ANL for HPR |  | 0.5d | 2009-10-02 | 2009-10-02 | 91 | 3d | 0d | start no earlier than 2009-09-11 |
| 133 | 1.15.2 | HPR Cavity |  | 3d | 2009-10-02 | 2009-10-07 | 132 | 3d | 0d | start no earlier than 2009-09-11 |
| 134 | 1.15.3 | Prep cavity for horizontal testing at CAF-MP9 |  | 5d | 2009-10-07 | 2009-10-14 | 133 | 3d |  | start no earlier than 2009-09-16 |
| 135 | 1.15.4 | Complete the engineering note and acquire test permission | milestone | 0d | 2009-10-05 | 2009-10-05 |  | 13.5d |  | start no earlier than 2009-10-05 |
| 136 | 1.15.5 | Install in HTS |  | 3d | 2009-10-19 | 2009-10-22 | 134, 129 | 0d |  | start no earlier than 2009-09-23 |
| 137 | 1.15.6 | Conduct tests |  | 10d | 2009-10-22 | 2009-11-05 | 135, 136 | 0d |  | start no earlier than 2009-09-28 |
| 138 | 1.15.7 | Test Cycle complete Cavity #3 | milestone | 0d | 2009-11-05 | 2009-11-05 | 137 | 0d |  | start no earlier than 2009-10-12 |
| 140 | 1.16 | **Test Cycle for CM2 Cavity #4** |  | 32.5d | 2009-10-09 | 2009-11-24 |  | 0d |  |  |
| 141 | 1.16.1 | Transport dressed cavity to ANL for HPR |  | 0.5d | 2009-10-09 | 2009-10-09 | 91FS+5d | 11d | 0d | start no earlier than 2009-09-11 |
| 142 | 1.16.2 | HPR Cavity |  | 3d | 2009-10-09 | 2009-10-14 | 141 | 11d | 0d | start no earlier than 2009-09-11 |
| 143 | 1.16.3 | Prep cavity for horizontal testing at CAF-MP9 |  | 5d | 2009-10-14 | 2009-10-21 | 142 | 11d |  | start no earlier than 2009-09-16 |
| 144 | 1.16.4 | Complete the engineering note and acquire test permission | milestone | 0d | 2009-10-19 | 2009-10-19 |  | 16.5d |  | start no earlier than 2009-10-19 |
| 145 | 1.16.5 | Install in HTS |  | 3d | 2009-11-05 | 2009-11-10 | 143, 138 | 0d |  | start no earlier than 2009-09-23 |
| 146 | 1.16.6 | Conduct tests |  | 10d | 2009-11-10 | 2009-11-24 | 144, 145 | 0d |  | start no earlier than 2009-09-28 |
| 147 | 1.16.7 | Test Cycle complete Cavity #4 | milestone | 0d | 2009-11-24 | 2009-11-24 | 146 | 0d |  | start no earlier than 2009-10-12 |
| 149 | 1.17 | **Test Cycle for CM2 Cavity #5** |  | 35.5d | 2009-10-23 | 2009-12-11 |  | 0d |  |  |
| 150 | 1.17.1 | Transport dressed cavity to ANL for HPR |  | 0.5d | 2009-10-23 | 2009-10-23 | 92 | 14d | 0d | start no earlier than 2009-09-11 |
| 151 | 1.17.2 | HPR Cavity |  | 3d | 2009-10-23 | 2009-10-28 | 150 | 14d | 0d | start no earlier than 2009-09-11 |
| 152 | 1.17.3 | Prep cavity for horizontal testing at CAF-MP9 |  | 5d | 2009-10-28 | 2009-11-04 | 151 | 14d |  | start no earlier than 2009-09-16 |
| 153 | 1.17.4 | Complete the engineering note and acquire test permission | milestone | 0d | 2009-11-02 | 2009-11-02 |  | 19.5d |  | start no earlier than 2009-11-02 |
| 154 | 1.17.5 | Install in HTS |  | 3d | 2009-11-24 | 2009-11-27 | 152, 147 | 0d |  | start no earlier than 2009-09-23 |
| 155 | 1.17.6 | Conduct tests |  | 10d | 2009-11-27 | 2009-12-11 | 153, 154 | 0d |  | start no earlier than 2009-09-28 |
| 156 | 1.17.7 | Test Cycle complete Cavity #5 | milestone | 0d | 2009-12-11 | 2009-12-11 | 155 | 0d |  | start no earlier than 2009-10-12 |

| ID | WBS | Task | Type | Duration | Start | Finish | Predecessors | Total slack | Free slack | Constraint |
| --- | --- | --- | --- | --- | --- | --- | --- | --- | --- | --- |
| 158 | 1.18 | **Test Cycle for CM2 Cavity #6** |  | 43.5d | 2009-10-30 | 2009-12-30 |  | 0d |  |  |
| 159 | 1.18.1 | Transport dressed cavity to ANL for HPR |  | 0.5d | 2009-10-30 | 2009-10-30 | 92FS+5d | 22d | 0d | start no earlier than 2009-09-11 |
| 160 | 1.18.2 | HPR Cavity |  | 3d | 2009-10-30 | 2009-11-04 | 159 | 22d | 0d | start no earlier than 2009-09-11 |
| 161 | 1.18.3 | Prep cavity for horizontal testing at CAF-MP9 |  | 5d | 2009-11-04 | 2009-11-11 | 160 | 22d |  | start no earlier than 2009-09-16 |
| 162 | 1.18.4 | Complete the engineering note and acquire test permission | milestone | 0d | 2009-11-16 | 2009-11-16 |  | 22.5d |  | start no earlier than 2009-11-16 |
| 163 | 1.18.5 | Install in HTS |  | 3d | 2009-12-11 | 2009-12-16 | 161, 156 | 0d |  | start no earlier than 2009-09-23 |
| 164 | 1.18.6 | Conduct tests |  | 10d | 2009-12-16 | 2009-12-30 | 162, 163 | 0d |  | start no earlier than 2009-09-28 |
| 165 | 1.18.7 | Test Cycle complete Cavity #6 | milestone | 0d | 2009-12-30 | 2009-12-30 | 164 | 0d |  | start no earlier than 2009-10-12 |
| 167 | 1.19 | **Test Cycle for CM2 Cavity #7** |  | 46.5d | 2009-11-13 | 2010-01-18 |  | 0d |  |  |
| 168 | 1.19.1 | Transport dressed cavity to ANL for HPR |  | 0.5d | 2009-11-13 | 2009-11-13 | 93 | 25d | 0d | start no earlier than 2009-09-11 |
| 169 | 1.19.2 | HPR Cavity |  | 3d | 2009-11-13 | 2009-11-18 | 168 | 25d | 0d | start no earlier than 2009-09-11 |
| 170 | 1.19.3 | Prep cavity for horizontal testing at CAF-MP9 |  | 5d | 2009-11-18 | 2009-11-25 | 169 | 25d |  | start no earlier than 2009-09-16 |
| 171 | 1.19.4 | Complete the engineering note and acquire test permission | milestone | 0d | 2009-11-30 | 2009-11-30 |  | 25.5d |  | start no earlier than 2009-11-30 |
| 172 | 1.19.5 | Install in HTS |  | 3d | 2009-12-30 | 2010-01-04 | 170, 165 | 0d |  | start no earlier than 2009-09-23 |
| 173 | 1.19.6 | Conduct tests |  | 10d | 2010-01-04 | 2010-01-18 | 171, 172 | 0d |  | start no earlier than 2009-09-28 |
| 174 | 1.19.7 | Test Cycle complete Cavity #7 | milestone | 0d | 2010-01-18 | 2010-01-18 | 173 | 0d |  | start no earlier than 2009-10-12 |
| 176 | 1.20 | **Test Cycle for CM2 Cavity #8** |  | 54.5d | 2009-11-20 | 2010-02-04 |  | 0d |  |  |
| 177 | 1.20.1 | Transport dressed cavity to ANL for HPR |  | 0.5d | 2009-11-20 | 2009-11-20 | 93FS+5d | 33d | 0d | start no earlier than 2009-09-11 |
| 178 | 1.20.2 | HPR Cavity |  | 3d | 2009-11-20 | 2009-11-25 | 177 | 33d | 0d | start no earlier than 2009-09-11 |
| 179 | 1.20.3 | Prep cavity for horizontal testing at CAF-MP9 |  | 5d | 2009-11-25 | 2009-12-02 | 178 | 33d |  | start no earlier than 2009-09-16 |
| 180 | 1.20.4 | Complete the engineering note and acquire test permission | milestone | 0d | 2009-12-14 | 2009-12-14 |  | 28.5d |  | start no earlier than 2009-12-14 |
| 181 | 1.20.5 | Install in HTS |  | 3d | 2010-01-18 | 2010-01-21 | 179, 174 | 0d |  | start no earlier than 2009-09-23 |
| 182 | 1.20.6 | Conduct tests |  | 10d | 2010-01-21 | 2010-02-04 | 180, 181 | 0d |  | start no earlier than 2009-09-28 |
| 183 | 1.20.7 | Test Cycle complete Cavity #8 | milestone | 0d | 2010-02-04 | 2010-02-04 | 182 | 0d |  | start no earlier than 2009-10-12 |
